# Migration of Health Professionals

Schedule from MS Project, 2009-01-01 to 2011-07-01.
cooperación easp

## Calendars

- Estándar: Mon-Fri 09:00-13:00, 15:00-19:00; Sat-Sun off.

## Resources

| Resource |
| --- |
| EASP |
| EASP-OPS-GTSEGIB |
| EASP-OPS |
| GTSEGIB |
| EXTERNAL EXPERTS |
| OPS-GTSEGIB-EASP |
| EASP-Ext. Consultants |
| EASP-OPS-External consultants |
| EASP (partner) |
| GTSEGIB (associated) |
| subcontrators EASP-OPS-GTSEGIB-COOP AGENCIES |
| OPS |
| OPS-EASP |
| OPS-EASP-GTSEGIB |
| EASP-GTSEGIB-OPS |
| GTSEGIB-EASP |
| OPS-EASP-GSEGIB |
| subcontrator |

## Schedule

| ID | WBS | Task | Duration | Start | Finish | Predecessors | Total slack | Free slack | Constraint | Resources | Work |
| --- | --- | --- | --- | --- | --- | --- | --- | --- | --- | --- | --- |
| 1 | 1 | **General organization** | 632d? | 2009-01-01 | 2011-06-03 |  | 20d |  |  |  | 10080h |
| 2 | 1.1 | Clarification with financing agency, methodological review | 5d? | 2009-01-05 | 2009-01-09 |  | 645d |  | start no earlier than 2009-01-05 |  |  |
| 3 | 1.2 | **Constitute a Committee and Technical Secretariat** | 22d? | 2009-01-01 | 2009-01-30 |  | 630d |  |  | EASP-OPS-GTSEGIB | 704h |
| 4 | 1.2.1 | Select permanent technician and other members | 22d? | 2009-01-01 | 2009-01-30 |  | 630d |  |  | EASP (partner) | 176h |
| 5 | 1.2.2 | Responsibilities and functions defined in a plan | 22d? | 2009-01-01 | 2009-01-30 |  | 630d |  |  | EASP (partner) | 176h |
| 6 | 1.2.3 | Content management design for www | 22d? | 2009-01-01 | 2009-01-30 |  | 630d |  |  | EASP | 176h |
| 7 | 1.3 | **internal and external marketing** | 147d? | 2009-02-02 | 2009-08-25 |  | 483d |  |  | EASP | 3400h |
| 8 | 1.3.1 | Select the action's key elements | 45d? | 2009-02-02 | 2009-04-03 |  | 585d |  | start no earlier than 2009-02-02 | EASP | 360h |
| 9 | 1.3.2 | External and internal analysis of the setting (health ministries, cooperation agencies) | 95d? | 2009-02-02 | 2009-06-12 |  | 535d |  | start no earlier than 2009-02-02 | GTSEGIB (associated) | 760h |
| 10 | 1.3.3 | Selection of internal target groups, end-users | 37d? | 2009-05-04 | 2009-06-23 |  | 528d |  | start no earlier than 2009-05-04 | EASP-OPS-GTSEGIB | 296h |
| 11 | 1.3.4 | Segmentation of external-internal market | 22d? | 2009-05-25 | 2009-06-23 |  | 528d |  | start no earlier than 2009-05-25 | EASP | 176h |
| 12 | 1.3.5 | Define products for each target group | 22d? | 2009-05-25 | 2009-06-23 |  | 528d |  | start no earlier than 2009-05-25 | EASP-OPS-GTSEGIB | 176h |
| 13 | 1.3.6 | Action plan (formats, instruments, actions) | 57d? | 2009-06-08 | 2009-08-25 |  | 483d |  | start no earlier than 2009-06-08 | EASP | 456h |
| 14 | 1.4 | Selection of key actors | 132d? | 2009-01-01 | 2010-02-11 |  | 361d |  |  | EASP-OPS-GTSEGIB | 1056h |
| 15 | 1.5 | Getting the actors involved | 615d? | 2009-01-26 | 2011-06-03 |  | 20d |  | start no earlier than 2009-01-26 | EASP-OPS-GTSEGIB | 4920h |
| 16 | 2 | **Relevant activities** | 647d? | 2009-01-01 | 2011-06-24 |  | 5d |  |  |  | 27624h |
| 17 | 2.1 | **1-1: Literature review and information related to the state of the issue** | 194d? | 2009-01-01 | 2009-09-29 |  | 458d |  |  | EASP | 4352h |
| 18 | 2.1.1 | Selection of information sources | 17d? | 2009-02-09 | 2009-03-03 |  | 608d |  | start no earlier than 2009-02-09 | EASP-OPS | 136h |
| 19 | 2.1.2 | Information gathering | 50d? | 2009-02-09 | 2009-04-17 |  | 575d |  | start no earlier than 2009-02-09 | EASP | 400h |
| 20 | 2.1.3 | Document revision and selection | 67d? | 2009-02-09 | 2009-05-12 |  | 558d |  | start no earlier than 2009-02-09 | EASP | 536h |
| 21 | 2.1.4 | Create a data base | 75d? | 2009-02-09 | 2009-05-22 |  | 550d |  | start no earlier than 2009-02-09 |  |  |
| 22 | 2.1.5 | Draft a provisional report | 25d? | 2009-04-20 | 2009-05-22 |  | 506d | 0d | start no earlier than 2009-04-20 | EASP | 200h |
| 23 | 2.1.6 | Select key informants | 82d? | 2009-01-01 | 2009-04-24 |  | 570d |  |  | OPS-EASP-GSEGIB | 656h |
| 24 | 2.1.7 | Design script for interviews, choose methodology | 22d? | 2009-05-25 | 2009-06-23 | 22 | 506d | 0d | start no earlier than 2009-04-27 | EASP | 176h |
| 25 | 2.1.8 | Elaborate a report | 87d? | 2009-06-01 | 2009-09-29 |  | 458d |  | start no earlier than 2009-06-01 | EASP | 696h |

| ID | WBS | Task | Duration | Start | Finish | Predecessors | Total slack | Free slack | Constraint | Resources | Work |
| --- | --- | --- | --- | --- | --- | --- | --- | --- | --- | --- | --- |
| 26 | 2.2 | **1-2: Design and implementation of quantitative multicenter study** | 268d? | 2009-06-24 | 2010-07-02 |  | 260d |  |  | EASP-OPS-External consultants | 4328h |
| 27 | 2.2.1 | Case selection | 22d? | 2009-06-24 | 2009-07-23 | 24 | 506d |  | start no earlier than 2009-05-18 | GTSEGIB-EASP | 176h |
| 28 | 2.2.2 | Protocol design | 27d? | 2009-07-13 | 2009-08-18 |  | 488d |  | start no earlier than 2009-07-13 | EASP | 216h |
| 29 | 2.2.3 | Subcontract the studies | 57d? | 2009-08-17 | 2009-11-03 |  | 266d | 0d | start no earlier than 2009-08-17 | EASP | 456h |
| 30 | 2.2.4 | Work supervision | 132d? | 2009-11-04 | 2010-05-06 | 29 | 266d | 6d |  | GTSEGIB-EASP | 1056h |
| 31 | 2.2.5 | Conclusions integrated into an IS | 35d? | 2010-05-17 | 2010-07-02 | 30 | 260d |  | start no earlier than 2010-05-17 | EASP | 280h |
| 32 | 2.3 | **1-3: Design and development of an information system** | 225d? | 2009-09-21 | 2010-07-30 |  | 240d |  |  | EASP-OPS | 4504h |
| 33 | 2.3.1 | Identification of sources | 22d? | 2009-09-21 | 2009-10-20 |  | 443d |  | start no earlier than 2009-09-21 | GTSEGIB | 176h |
| 34 | 2.3.2 | Information systematization | 42d? | 2009-10-05 | 2009-12-01 |  | 413d |  | start no earlier than 2009-10-05 | GTSEGIB | 336h |
| 35 | 2.3.3 | Characteristics of the population who will be using the tool | 17d? | 2009-09-21 | 2009-10-13 |  | 448d |  | start no earlier than 2009-09-21 | GTSEGIB | 136h |
| 36 | 2.3.4 | Content management design for www | 67d? | 2009-10-12 | 2010-01-12 |  | 383d |  | start no earlier than 2009-10-12 | EASP-GTSEGIB-OPS | 536h |
| 37 | 2.3.5 | Development and implementation | 190d? | 2009-11-09 | 2010-07-30 |  | 220d | 0d | start no earlier than 2009-11-09 | EASP-OPS | 1520h |
| 38 | 2.4 | **2-1: Design and develop management proposals to guide bi-directional flows** | 161d? | 2009-11-30 | 2010-07-12 |  | 254d |  |  | OPS-GTSEGIB-EASP | 2288h |
| 39 | 2.4.1 | Draw conclusions from interveiws with key informants | 80d? | 2009-11-30 | 2010-04-19 |  | 314d |  | start no earlier than 2009-11-30 | EASP-OPS | 640h |
| 40 | 2.4.2 | Seminar for brainstorming and consensus-building | 5d? | 2010-03-29 | 2010-05-03 |  | 304d |  | start no earlier than 2010-03-29 | EASP | 40h |
| 41 | 2.4.3 | Dissemination and feedback of experience | 40d? | 2010-04-12 | 2010-07-12 |  | 254d |  | start no earlier than 2010-04-12 | EASP | 320h |
| 42 | 2.5 | **2-2: Prepare a methodological guide for human resources planning** | 110d? | 2010-02-01 | 2010-07-02 |  | 260d |  |  | EASP-OPS-GTSEGIB | 2032h |
| 43 | 2.5.1 | Regional situation report | 57d? | 2010-02-01 | 2010-04-20 |  | 295d | 0d | start no earlier than 2010-02-01 | GTSEGIB | 456h |
| 44 | 2.5.2 | Define goals | 57d? | 2010-02-01 | 2010-04-20 |  | 313d |  | start no earlier than 2010-02-01 | GTSEGIB | 456h |
| 45 | 2.5.3 | Design Seminar | 10d? | 2010-05-17 | 2010-05-28 |  | 285d |  | start no earlier than 2010-05-17 | EASP-GTSEGIB-OPS | 80h |
| 46 | 2.5.4 | Dissemination and feedback of experience | 20d? | 2010-06-07 | 2010-07-02 |  | 245d | 10d | start no earlier than 2010-06-07 | GTSEGIB | 160h |
| 47 | 2.6 | **2-3: Training process and workshops human resources for health planning.** | 95d? | 2010-06-28 | 2010-11-05 |  | 170d |  |  | EASP-OPS | 1680h |
| 48 | 2.6.1 | Define pedalogical goals | 25d? | 2010-06-28 | 2010-07-30 |  | 240d |  | start no earlier than 2010-06-28 | OPS-EASP-GTSEGIB | 200h |
| 49 | 2.6.2 | Design the activity in a virtual environment | 15d? | 2010-08-02 | 2010-08-20 |  | 225d |  | start no earlier than 2010-08-02 | OPS-EASP | 120h |
| 50 | 2.6.3 | Design teaching material for a virtual envrionment | 40d? | 2010-08-16 | 2010-10-08 |  | 190d |  | start no earlier than 2010-08-16 | OPS | 320h |
| 51 | 2.6.4 | Validation and training seminar | 5d? | 2010-09-20 | 2010-09-24 |  | 200d |  | start no earlier than 2010-09-20 | OPS | 40h |
| 52 | 2.6.5 | Incorporation into the virual campus | 30d? | 2010-09-27 | 2010-11-05 |  | 155d | 10d | start no earlier than 2010-09-27 | OPS | 240h |

| ID | WBS | Task | Duration | Start | Finish | Predecessors | Total slack | Free slack | Constraint | Resources | Work |
| --- | --- | --- | --- | --- | --- | --- | --- | --- | --- | --- | --- |
| 53 | 2.7 | **2-4: Definition of policies and cooperation strategies to manage migration flows** | 410d? | 2009-06-29 | 2011-01-21 |  | 115d |  |  | EASP-OPS-GTSEGIB | 6160h |
| 54 | 2.7.1 | Encourage the involvement of cooperation agencies | 60d? | 2009-10-05 | 2009-12-25 |  | 395d |  | start no earlier than 2009-10-05 | EASP-OPS | 480h |
| 55 | 2.7.2 | Selection of experiences | 155d? | 2009-06-29 | 2010-01-29 |  | 370d |  | start no earlier than 2009-06-29 | EASP | 1240h |
| 56 | 2.7.3 | Design initial proposals | 55d? | 2010-01-11 | 2010-03-26 |  | 330d |  | start no earlier than 2010-01-11 | EASP-OPS-GTSEGIB | 440h |
| 57 | 2.7.4 | Contract key speakers | 80d? | 2010-03-15 | 2010-07-02 |  | 260d |  | start no earlier than 2010-03-15 | subcontrators EASP-OPS-GTSEGIB-COOP AGENCIES | 640h |
| 58 | 2.7.5 | Consensus conference | 10d? | 2011-01-10 | 2011-01-21 |  | 95d | 75d | start no earlier than 2011-01-10 | EASP | 80h |
| 59 | 2.8 | **3-1: Review the processes generated and the products obtained** | 150d? | 2010-11-29 | 2011-06-24 |  | 5d |  |  | EASP-Ext. Consultants | 2280h |
| 60 | 2.8.1 | Forward the information to selected actors | 90d? | 2010-11-29 | 2011-04-01 |  | 65d |  | start no earlier than 2010-11-29 | EASP | 720h |
| 61 | 2.8.2 | Feedback | 25d? | 2011-03-07 | 2011-04-08 |  | 40d | 35d | start no earlier than 2011-03-07 | EASP | 200h |
| 62 | 2.8.3 | Final systematization | 20d? | 2011-05-30 | 2011-06-24 | 61 | 5d |  | start no earlier than 2011-05-30 | EASP-OPS-GTSEGIB | 160h |
| 63 | 3 | **Products** | 313d? | 2010-04-21 | 2011-07-01 |  | 0d |  |  |  |  |
| 64 | 3.1 | State of the situation established | 18d? | 2010-04-21 | 2010-05-14 | 43 | 295d |  | start no earlier than 2010-04-19 |  |  |
| 65 | 3.2 | Information system designed and operating | 20d? | 2010-08-02 | 2010-08-27 | 37 | 220d |  | start no earlier than 2010-08-02 |  |  |
| 66 | 3.3 | Human Resources planning guide produced | 15d? | 2010-07-19 | 2010-08-06 | 46 | 235d |  | start no earlier than 2010-07-19 |  |  |
| 67 | 3.4 | Courses designed and made available on virtual campus | 15d? | 2010-11-22 | 2010-12-10 | 52 | 145d |  | start no earlier than 2010-11-22 |  |  |
| 68 | 3.5 | Cooperation strategies on the issue formulated by consensus | 20d? | 2011-05-09 | 2011-06-03 | 58 | 20d |  | start no earlier than 2011-05-09 |  |  |
| 69 | 3.6 | Publication of results | 72d? | 2010-05-17 | 2011-07-01 |  | 0d |  | start no earlier than 2010-05-17 |  |  |
| 70 | 3.7 | Dissemination and feedback of experience | 230d? | 2010-08-09 | 2011-06-24 |  | 5d |  | start no earlier than 2010-08-09 |  |  |
| 71 | 4 | **Expected results** | 230d? | 2010-08-16 | 2011-07-01 |  | 0d |  |  |  |  |
| 72 | 4.1 | Result 1: Migration flows characterized. | 230d? | 2010-08-16 | 2011-07-01 |  | 0d |  | start no earlier than 2010-08-16 |  |  |
| 73 | 4.2 | Result 2: Management guide elaborated on the subject of migrant health workers' mobility | 65d? | 2011-04-04 | 2011-07-01 |  | 0d |  | start no earlier than 2011-04-04 |  |  |
| 74 | 4.3 | Result 3: The experience is evaluated and systematized | 65d? | 2011-04-04 | 2011-07-01 |  | 0d |  | start no earlier than 2011-04-04 |  |  |
| 75 | 5 | Specify visibility actions | 47d? | 2009-02-23 | 2011-06-03 |  | 20d |  | start no earlier than 2009-02-23 |  |  |
| 76 | 6 | Audit | 37d? | 2009-12-21 | 2011-07-01 |  | 0d |  | start no earlier than 2009-12-21 | subcontrator | 296h |
| 77 | 7 | Final evaluation | 12d? | 2011-06-13 | 2011-06-28 |  | 3d |  | start no earlier than 2011-06-13 | subcontrator | 96h |
